Schedule from MS Project, 2023-05-15 to 2023-06-13, costs in S.
Microsoft

## Calendars

- real: Mon-Fri 07:00-12:00, 14:00-17:00; Sat 07:00-24:00; Sun off.

## Schedule

| ID | WBS | Task | Duration | Start | Finish | Predecessors | Total slack | Cost |
| --- | --- | --- | --- | --- | --- | --- | --- | --- |
| 1 | 1 | **CONSTRUCCION DE VEREDA Y SARDINEL, ADQUISICION DE MOBILIARIO URBANO, EN EL(LA) CALLE REAL EN LA LOCALIDAD CARTAVIO, DISTRITO DE SANTIAGO DE CAO, PROVINCIA ASCOPE, DEPARTAMENTO LA LIBERTAD** | 30d | 2023-05-15 | 2023-06-13 |  | 0d | 192,946.01 |
| 2 | 1.1 | **OBRAS PROVISIONALES** | 1d | 2023-05-15 | 2023-05-15 |  | 0d | 2,080.65 |
| 3 | 1.1.1 | CARTEL DE OBRA 2.40X3.60 INCLUYE LA INSTALACION | 1d | 2023-05-15 | 2023-05-15 |  | 0d | 1,080.65 |
| 4 | 1.1.2 | MOVILIZACION Y DESMOVILIZACION DE EQUIPOS Y HERRAMIENTAS | 1d | 2023-05-15 | 2023-05-15 | 3SS | 0d | 1,000 |
| 5 | 1.2 | **SEGURIDAD Y SALUD** | 1d | 2023-05-16 | 2023-05-16 | 2 | 0d | 2,441.36 |
| 6 | 1.2.1 | ELABORACION,IMPLEMENTACION Y ADMIISTRACION DE PLAN DE SEGURIDAD Y SALUD EN EL TRABAJO | 1d | 2023-05-16 | 2023-05-16 |  | 0d | 1,036.76 |
| 7 | 1.2.2 | EQUIPOS DE PROTECCION INDIVIDUAL | 1d | 2023-05-16 | 2023-05-16 | 6SS | 0d | 1,404.6 |
| 8 | 1.3 | **BANCAS** | 5d | 2023-05-17 | 2023-05-20 | 5 | 0d | 34,321.86 |
| 9 | 1.3.1 | SUMINISTRO E INSTALACION DE BANCAS | 5d | 2023-05-17 | 2023-05-20 |  | 0d | 34,321.86 |
| 10 | 1.4 | **RAMPAS** | 3d | 2023-05-20 | 2023-05-24 | 8 | 0d | 7,376.35 |
| 11 | 1.4.1 | TRAZO,NIVELACION Y REPLANTEO EN RAMPAS | 1d | 2023-05-20 | 2023-05-22 |  | 0d | 1,031.39 |
| 12 | 1.4.2 | EXCAVACION MANUAL DE MATERIAL SUELTO EN RAMPAS | 1d | 2023-05-20 | 2023-05-22 | 11SS | 0d | 325.13 |
| 13 | 1.4.3 | ELIMINACION DE MATERIAL EXCEDENTE PROVENIENTE DE LA EXCAVACION (D.PROM=5KM) | 1d | 2023-05-20 | 2023-05-22 | 12SS | 0d | 605.79 |
| 14 | 1.4.4 | PERFILADO Y COMPACTADO DE SUBRASANTE EN RAMPAS | 1d | 2023-05-20 | 2023-05-22 | 13SS | 0d | 2,804.95 |
| 15 | 1.4.5 | CONFORMACION DE BASE GRANULAR PARA RAMPAS E=0.10m | 1d | 2023-05-22 | 2023-05-23 | 14 | 0d | 430.63 |
| 16 | 1.4.6 | ENCOFRADO Y DESENCOFRADO NORMAL EN RAMPAS | 1d | 2023-05-22 | 2023-05-23 | 15SS | 0d | 1,159.33 |
| 17 | 1.4.7 | CONCRETO F´C=175 KG/CM2 EN RAMPAS | 2d | 2023-05-22 | 2023-05-24 | 16SS | 0d | 1,019.13 |
| 18 | 1.5 | **SARDINELES** | 4d | 2023-05-24 | 2023-05-27 | 10 | 0d | 16,129.81 |
| 19 | 1.5.1 | **SARDINELES SUMERGIDOS** | 2d | 2023-05-24 | 2023-05-26 |  | 0d | 10,075.79 |
| 20 | 1.5.1.1 | TRAZO,NIVELACION Y REPLANTEO EN SARDINELES SUMERGIDOS | 1d | 2023-05-24 | 2023-05-25 |  | 0d | 2,034.13 |
| 21 | 1.5.1.2 | EXCAVACION MANUAL DE MATERIAL SUELTO EN SARDINELES SUMERGIDOS | 1d | 2023-05-24 | 2023-05-25 | 20SS | 0d | 546.69 |
| 22 | 1.5.1.3 | ELIMINACION DE MATERIAL EXCEDENTE PROVENIENTE DE LA EXCAVACION (D.PROM=5KM) | 1d | 2023-05-24 | 2023-05-25 | 21SS | 0d | 1,018.38 |
| 23 | 1.5.1.4 | ENCOFRADO Y DESENCOFRADO NORMAL DE SARDINELES SUMERGIDOS | 2d | 2023-05-24 | 2023-05-26 | 22SS | 0d | 4,762.97 |
| 24 | 1.5.1.5 | CONCRETO F´C=175 KG/CM2 EN SARDINELES SUMERGIDOS | 2d | 2023-05-24 | 2023-05-26 | 23SS | 0d | 1,713.62 |

| ID | WBS | Task | Duration | Start | Finish | Predecessors | Total slack | Cost |
| --- | --- | --- | --- | --- | --- | --- | --- | --- |
| 25 | 1.5.2 | **SARDINELES PERALTADOS** | 2d | 2023-05-26 | 2023-05-27 | 19 | 0d | 6,054.02 |
| 26 | 1.5.2.1 | TRAZO,NIVELACION Y REPLANTEO EN SARDINELES PERALTADOS | 2d | 2023-05-26 | 2023-05-27 |  | 0d | 1,221.94 |
| 27 | 1.5.2.2 | EXCAVACION MANUAL DE MATERIAL SUELTO EN SARDINELES | 1d | 2023-05-26 | 2023-05-27 | 26SS | 0d | 328.62 |
| 28 | 1.5.2.3 | ELIMINACION DE MATERIAL EXCEDENTE PROVENIENTE DE LA EXCAVACION (D.PROM=5KM) | 1d | 2023-05-26 | 2023-05-27 | 27SS | 0d | 612.16 |
| 29 | 1.5.2.4 | ENCOFRADO Y DESENCOFRADO NORMAL DE SARDINELES PERALTADOS | 2d | 2023-05-26 | 2023-05-27 | 28SS | 0d | 2,861.21 |
| 30 | 1.5.2.5 | CONCRETO F´C=175 KG/CM2 EN SARDINELES PERALTADOS | 2d | 2023-05-26 | 2023-05-27 | 29SS | 0d | 1,030.09 |
| 31 | 1.6 | **JARDINERAS** | 2d | 2023-05-27 | 2023-05-30 | 18 | 0d | 10,603.81 |
| 32 | 1.6.1 | CONCRETO F´C=175 KG/CM2 EN JARDINERAS | 2d | 2023-05-27 | 2023-05-30 |  | 0d | 439.71 |
| 33 | 1.6.2 | SEMBRADO DE TIERRA CHACRA | 1d | 2023-05-27 | 2023-05-29 | 32SS | 0d | 3,158.42 |
| 34 | 1.6.3 | COLOCACION DE ARBOL ORNAMENTAL EN JARDINERAS | 2d | 2023-05-27 | 2023-05-30 | 33SS | 0d | 7,005.68 |
| 35 | 1.7 | **VEREDAS** | 4d | 2023-05-30 | 2023-06-03 | 31 | 0d | 10,393.84 |
| 36 | 1.7.1 | TRAZO, NIVELACION Y REPLANTEO EN PISO ADOQUINADO | 1d | 2023-05-30 | 2023-05-31 |  | 0d | 1,809.74 |
| 37 | 1.7.2 | EXCAVACION MANUAL DE MATERIAL SUELTO EN PISO DE ADOQUIN | 2d | 2023-05-30 | 2023-06-01 | 36SS | 0d | 324.25 |
| 38 | 1.7.3 | ELIMINACION DE MATERIAL EXCEDENTE PROVENIENTE DE LA EXCAVACION (D.PROM=5KM) | 1d | 2023-05-30 | 2023-05-31 | 37SS | 0d | 603.67 |
| 39 | 1.7.4 | CONFORMACION DE BASE GRANULAR PARA ADOQUIN E=0.15 m | 1d | 2023-05-30 | 2023-05-31 | 38SS | 0d | 966.31 |
| 40 | 1.7.5 | REVESTIMIENTO DE PISO CON ADOQUINES DE CONCRETO 0.10X0.20X0.04 COLOR ROJO | 3d | 2023-05-31 | 2023-06-03 | 39 | 0d | 6,689.87 |
| 41 | 1.8 | **PINTURA** | 7d | 2023-06-03 | 2023-06-10 | 35 | 0d | 86,153.37 |
| 42 | 1.8.1 | BARNIZADO EN SUPERFICIE DE MADERA | 5d | 2023-06-03 | 2023-06-08 |  | 0d | 7,895.07 |
| 43 | 1.8.2 | PINTADO DE ADOQUINADO A DOS MANOS | 4d | 2023-06-03 | 2023-06-07 | 42SS | 0d | 71,301.3 |
| 44 | 1.8.3 | PINTADO DE SARDINEL A DOS MANOS | 3d | 2023-06-07 | 2023-06-10 | 43 | 0d | 6,957 |
| 45 | 1.9 | **VARIOS** | 3d | 2023-06-10 | 2023-06-13 | 41 | 0d | 23,444.96 |
| 46 | 1.9.1 | SUMINISTRO E INSTALACION DE MARCO CON TAPA DE CONCRETO ARMADO PARA DESAGUE Y AGUA | 3d | 2023-06-10 | 2023-06-13 |  | 0d | 23,444.96 |
